# PLOEGEN SCHEMA kantoorgebouw

Schedule from MS Project, 2004-06-01 to 2005-03-17, status date 2003-06-02.
BAM Nelissen Van Egteren

## Calendars

- afbouw kalender: Mon-Fri 08:30-12:30, 13:00-17:00; Sat-Sun off. Exceptions (off unless hours are given): 2004-07-19 to 2004-07-23, 2004-07-26 to 2004-07-30, 2004-08-02 to 2004-08-06, 2004-12-27 to 2004-12-31, 2005-01-03 to 2005-01-07, 2005-02-07 to 2005-02-08.

## Resources

| Resource |
| --- |
| vloerpl |
| montpl |
| grondpl |
| kistploeg |
| betonpl |
| maatv |
| heier |
| vlechter |
| loodg |
| dakdekk |
| metselpl |
| steigerpl |
| staalpl |
| wandpl |
| kolompl |

## Schedule

| ID | WBS | Task | Duration | Start | Finish | Predecessors | Total slack | Free slack | Text1 | Text5 |
| --- | --- | --- | --- | --- | --- | --- | --- | --- | --- | --- |
| 1 | 1 | **AANLOOPFASE** | 20d | 2004-06-01 | 2004-06-28 |  | 0d |  |  |  |
| 2 | 1.1 | **bouwplaats inrichten** | 6d | 2004-06-01 | 2004-06-08 |  | 0d |  |  |  |
| 3 | 1.1.1 | bouwafrastering plaatsen | 3d | 2004-06-01 | 2004-06-03 |  | 0d |  | m1 | montpl |
| 4 | 1.1.2 | containerketen plaatsen | 3d | 2004-06-01 | 2004-06-03 | 3SS | 177.15d |  | st | montpl |
| 5 | 1.1.3 | bouw installaties monteren | 4d | 2004-06-03 | 2004-06-08 | 3SS+2d | 174.15d |  | m1 | montpl |
| 6 | 1.2 | **bouwput maken** | 6d | 2004-06-04 | 2004-06-11 |  | 0d |  |  |  |
| 7 | 1.2.1 | uitzetten tbv grondwerk | 2d | 2004-06-04 | 2004-06-07 | 3SS+3d | 0d |  | m2 | maatv |
| 8 | 1.2.2 | ontgraven bouwput | 4d | 2004-06-08 | 2004-06-11 | 7 | 0d |  | m3 | grond |
| 9 | 1.3 | **paalfundatie maken** | 11d | 2004-06-14 | 2004-06-28 |  | 0d |  |  |  |
| 10 | 1.3.1 | bouwplanken+heipiketten | 2d | 2004-06-14 | 2004-06-15 | 8 | 0d |  | m1 | maatv |
| 11 | 1.3.2 | heiwerk prefab palen | 6d | 2004-06-16 | 2004-06-23 | 10 | 0d |  | st | heier |
| 12 | 1.3.3 | paalkoppen snellen | 3d | 2004-06-24 | 2004-06-28 | 11 | 0d |  | st | heier |
| 13 | 2 | **ONDERBOUW FASE** | 15d | 2004-06-28 | 2004-07-16 |  | 0d |  |  |  |
| 14 | 2.1 | **funderings balken** | 8d | 2004-06-28 | 2004-07-07 |  | 0d |  |  |  |
| 15 | 2.1.1 | werkvloer kist+beton | 5d | 2004-06-28 | 2004-07-02 | 12SS+2d | 0d |  | m1 | fundpl |
| 16 | 2.1.2 | wapening fund.balken | 5d | 2004-06-29 | 2004-07-05 | 15SS+1d | 0d |  | m1 | vlechtpl |
| 17 | 2.1.3 | balkbekisting stellen | 5d | 2004-06-30 | 2004-07-06 | 16SS+1d | 0d |  | m1 | fundpl |
| 18 | 2.1.4 | funderingsbalken storten | 5d | 2004-07-01 | 2004-07-07 | 17SS+1d | 0d |  | m1 | fundpl |
| 19 | 2.2 | **funderings poeren** | 9d | 2004-06-28 | 2004-07-08 |  | 152.15d |  |  |  |
| 20 | 2.2.1 | werkvloer+bekisting | 6d | 2004-06-28 | 2004-07-05 | 12SS+2d | 152.15d | 0d | st | fundpl |
| 21 | 2.2.2 | wapening poeren | 6d | 2004-06-30 | 2004-07-07 | 20SS+2d | 152.15d | 0d | ton | vlechtpl |
| 22 | 2.2.3 | poeren beton storten | 6d | 2004-07-01 | 2004-07-08 | 21SS+1d | 152.15d |  | st | fundpl |
| 23 | 2.3 | **beg,grondvloer kruipruimte** | 5d | 2004-07-05 | 2004-07-09 |  | 151.15d |  |  |  |
| 24 | 2.3.1 | riolering in kruipruimte | 2d | 2004-07-05 | 2004-07-06 | 18SS+2d | 151.15d | 0d | m1 | loodgie |
| 25 | 2.3.2 | systeemvloer leggen | 2d | 2004-07-07 | 2004-07-08 | 24 | 151.15d | 0d | m2 | fundpl |
| 26 | 2.3.3 | systeemvloer afstorten | 1d | 2004-07-09 | 2004-07-09 | 25 | 151.15d |  | m2 | betonpl |

| ID | WBS | Task | Type | Duration | Start | Finish | Predecessors | Total slack | Free slack | Constraint | Text1 | Text5 |
| --- | --- | --- | --- | --- | --- | --- | --- | --- | --- | --- | --- | --- |
| 27 | 2.4 | **beg.grondvloer op zand** |  | 10d | 2004-07-05 | 2004-07-16 |  | 0d |  |  |  |  |
| 28 | 2.4.1 | zandaanvulling aanbrengen |  | 4d | 2004-07-05 | 2004-07-08 | 18SS+2d | 0d |  |  | m3 | grond |
| 29 | 2.4.2 | werkvloer+isolatie aanbr |  | 5d | 2004-07-07 | 2004-07-13 | 28SS+2d | 0d |  |  | m2 | fundpl |
| 30 | 2.4.3 | wapening vloer vlechten |  | 5d | 2004-07-09 | 2004-07-15 | 29SS+2d | 0d |  |  | ton | vlechtpl |
| 31 | 2.4.4 | beg.grondvloer storten |  | 2d | 2004-07-15 | 2004-07-16 | 30SS+4d | 0d |  |  | m3 | betonpl |
| 32 | 2.4.5 | mijlpaal beg.gr.vloer gestort wk 29 | milestone | 0d | 2004-07-15 | 2004-07-15 |  | 148.15d |  | start no earlier than 2004-07-15 |  |  |
| 33 | 3 | **BOVENBOUW FASE** |  | 92d | 2004-08-09 | 2004-12-15 |  | 0d |  |  |  |  |
| 34 | 3.1 | **beg.grond wand-kolom-balk** |  | 16d | 2004-08-09 | 2004-08-30 |  | 0d |  |  |  |  |
| 35 | 3.1.1 | betonwanden kist+wap+beton |  | 10d | 2004-08-09 | 2004-08-20 | 31 | 136.15d |  |  | st | wandpl |
| 36 | 3.1.2 | middenkolommen kist+wap+beton |  | 10d | 2004-08-09 | 2004-08-20 | 31 | 136.15d |  |  | st | kolompl |
| 37 | 3.1.3 | gevelkolommen kist+wap+beton |  | 12.9d | 2004-08-09 | 2004-08-25 | 31 | 0d |  |  | st | kolompl |
| 38 | 3.1.4 | prefab gevelbalken stellen |  | 13d | 2004-08-12 | 2004-08-30 | 37SS+3d | 0d |  |  | st | wandpl |
| 39 | 3.2 | **1e verdiepingsvloer** |  | 21d | 2004-08-16 | 2004-09-13 |  | 0d |  |  |  |  |
| 40 | 3.2.1 | vloerbekisting stellen |  | 17.01d | 2004-08-16 | 2004-09-08 | 38SS+2d | 0d |  |  | m2 | kistpl |
| 41 | 3.2.2 | vloer wapening vlechten |  | 17.33d | 2004-08-19 | 2004-09-13 | 40SS+3d | 112.55d | 0d |  | ton | vlechtpl |
| 42 | 3.2.3 | vloer storten links-midd-rechts |  | 3d | 2004-08-26 | 2004-09-13 | 41SS+5d | 112.55d | 0d |  | m3 | betonpl |
| 43 | 3.2.4 | mijlpaal vloer 1 gestort wk 37 | milestone | 0d | 2004-09-09 | 2004-09-09 |  | 123.15d |  | start no earlier than 2004-09-09 |  |  |
| 44 | 3.3 | **1e verd, wand-kolom-balk** |  | 18.6d | 2004-08-30 | 2004-09-23 |  | 112.55d |  |  |  |  |
| 45 | 3.3.1 | betonwanden kist+wap+beton |  | 16.13d | 2004-08-30 | 2004-09-21 | 42SS+2d | 115.02d |  |  | st | wandpl |
| 46 | 3.3.2 | middenkolommen kist+wap+beton |  | 16.13d | 2004-08-30 | 2004-09-21 | 42SS+2d | 115.02d |  |  | st | kolompl |
| 47 | 3.3.3 | gevelkolommen kist+wap+beton |  | 16d | 2004-08-30 | 2004-09-20 | 42SS+2d | 112.55d | 0d |  | st | kolompl |
| 48 | 3.3.4 | prefab gevelbalken stellen |  | 15.6d | 2004-09-02 | 2004-09-23 | 47SS+3d | 112.55d |  |  | st | wandpl |
| 49 | 3.4 | **2e verdiepingsvloer** |  | 20d | 2004-09-08 | 2004-10-06 |  | 0d |  |  |  |  |
| 50 | 3.4.1 | vloerbekisting stellen |  | 16.13d | 2004-09-08 | 2004-09-30 | 40 | 0d |  |  | m2 | kistpl |
| 51 | 3.4.2 | vloer wapening vlechten |  | 16.25d | 2004-09-13 | 2004-10-05 | 50SS+3d | 96.14d | 0d |  | ton | vlechtpl |
| 52 | 3.4.3 | vloer storten links-midd-rechts |  | 3d | 2004-09-20 | 2004-10-06 | 51SS+5d | 96.14d | 0d |  | m3 | betonpl |
| 53 | 3.4.4 | mijlpaal vloer 2 gestort wk 40 | milestone | 0d | 2004-09-30 | 2004-09-30 |  | 108.15d |  | start no earlier than 2004-09-30 |  |  |

| ID | WBS | Task | Type | Duration | Start | Finish | Predecessors | Total slack | Free slack | Constraint | Text1 | Text5 |
| --- | --- | --- | --- | --- | --- | --- | --- | --- | --- | --- | --- | --- |
| 54 | 3.5 | **2e verd, wand-kolom-balk** |  | 18d | 2004-09-22 | 2004-10-18 |  | 96.14d |  |  |  |  |
| 55 | 3.5.1 | betonwanden kist+wap+beton |  | 14.93d | 2004-09-22 | 2004-10-12 | 52SS+2d | 99.21d |  |  | st | wandpl |
| 56 | 3.5.2 | middenkolommen kist+wap+beton |  | 14.93d | 2004-09-22 | 2004-10-12 | 52SS+2d | 99.21d |  |  | st | kolompl |
| 57 | 3.5.3 | gevelkolommen kist+wap+beton |  | 15.38d | 2004-09-22 | 2004-10-13 | 52SS+2d | 96.14d | 0d |  | st | kolompl |
| 58 | 3.5.4 | prefab gevelbalken stellen |  | 15d | 2004-09-27 | 2004-10-18 | 57SS+3d | 96.14d |  |  | st | wandpl |
| 59 | 3.6 | **3e verdiepingsvloer** |  | 19.86d | 2004-09-30 | 2004-10-28 |  | 0d |  |  |  |  |
| 60 | 3.6.1 | vloerbekisting stellen |  | 14.93d | 2004-09-30 | 2004-10-21 | 50 | 0d |  |  | m2 | kistpl |
| 61 | 3.6.2 | vloer wapening vlechten |  | 15.29d | 2004-10-05 | 2004-10-26 | 60SS+3d | 46.41d | 0d |  | ton | vlechtpl |
| 62 | 3.6.3 | vloer storten links-midd-rechts |  | 3d | 2004-10-12 | 2004-10-27 | 61SS+5d | 46.41d | 0d |  | m3 | betonpl |
| 63 | 3.6.4 | mijlpaal vloer 3 gestort wk 44 | milestone | 0d | 2004-10-28 | 2004-10-28 |  | 88.15d |  | start no earlier than 2004-10-28 |  |  |
| 64 | 3.7 | **3e verd, wand-kolom-balk** |  | 16.93d | 2004-10-14 | 2004-11-08 |  | 46.41d |  |  |  |  |
| 65 | 3.7.1 | betonwanden kist+wap+beton |  | 14.29d | 2004-10-14 | 2004-11-03 | 62SS+2d | 83.72d |  |  | st | wandpl |
| 66 | 3.7.2 | middenkolommen kist+wap+beton |  | 14.29d | 2004-10-14 | 2004-11-03 | 62SS+2d | 83.72d |  |  | st | kolompl |
| 67 | 3.7.3 | gevelkolommen kist+wap+beton |  | 14.29d | 2004-10-14 | 2004-11-03 | 62SS+2d | 46.41d | 0d |  | st | kolompl |
| 68 | 3.7.4 | prefab gevelbalken stellen |  | 13.93d | 2004-10-19 | 2004-11-08 | 67SS+3d | 46.41d | 0d |  | st | wandpl |
| 69 | 3.8 | **4e verdiepingsvloer** |  | 19.93d | 2004-10-21 | 2004-11-18 |  | 0d |  |  |  |  |
| 70 | 3.8.1 | vloerbekisting stellen |  | 14.08d | 2004-10-21 | 2004-11-10 | 60 | 0d |  |  | m2 | kistpl |
| 71 | 3.8.2 | vloer wapening vlechten |  | 14.05d | 2004-10-26 | 2004-11-15 | 70SS+3d | 67.15d | 0d |  | ton | vlechtpl |
| 72 | 3.8.3 | vloer storten links-midd-rechts |  | 3d | 2004-11-01 | 2004-11-16 | 71SS+4d | 67.15d | 0d | start no earlier than 2004-10-31 | m3 | betonpl |
| 73 | 3.8.4 | mijlpaal vloer 4 gestort wk 47 | milestone | 0d | 2004-11-18 | 2004-11-18 |  | 73.15d |  | start no earlier than 2004-11-18 |  |  |
| 74 | 3.9 | **4e verd, wand-kolom-balk** |  | 16.93d | 2004-11-03 | 2004-11-25 |  | 67.15d |  |  |  |  |
| 75 | 3.9.1 | betonwanden kist+wap+beton |  | 14.29d | 2004-11-03 | 2004-11-23 | 72SS+2d | 69.79d |  |  | st | wandpl |
| 76 | 3.9.2 | middenkolommen kist+wap+beton |  | 14.29d | 2004-11-03 | 2004-11-23 | 72SS+2d | 69.79d |  |  | st | kolompl |
| 77 | 3.9.3 | gevelkolommen kist+wap+beton |  | 14.29d | 2004-11-03 | 2004-11-23 | 72SS+2d | 67.15d | 0d |  | st | kolompl |
| 78 | 3.9.4 | prefab gevelbalken stellen |  | 13.93d | 2004-11-08 | 2004-11-25 | 77SS+3d | 67.15d |  |  | st | wandpl |

| ID | WBS | Task | Type | Duration | Start | Finish | Predecessors | Total slack | Free slack | Constraint | Text1 | Text5 |
| --- | --- | --- | --- | --- | --- | --- | --- | --- | --- | --- | --- | --- |
| 79 | 3.10 | **dakvloer** |  | 24.85d | 2004-11-10 | 2004-12-15 |  | 0d |  |  |  |  |
| 80 | 3.10.1 | vloerbekisting stellen |  | 14.08d | 2004-11-10 | 2004-11-30 | 70 | 0d |  |  | m2 | kistpl |
| 81 | 3.10.2 | vloer wapening vlechten |  | 14.05d | 2004-11-15 | 2004-12-03 | 80SS+3d | 0d |  |  | ton | vlechtpl |
| 82 | 3.10.3 | vloer storten links-midd-rechts |  | 3d | 2004-11-19 | 2004-12-06 | 81SS+4d | 0d |  | start no earlier than 2004-10-31 | m3 | betonpl |
| 83 | 3.10.4 | mijlpaal dakvloer gestort wk 51 | milestone | 0d | 2004-12-15 | 2004-12-15 |  | 54.15d |  | start no earlier than 2004-12-15 |  |  |
| 84 | 4 | **GEVEL / DAK FASE** |  | 81.08d | 2004-11-08 | 2005-03-17 |  | 0d |  |  |  |  |
| 85 | 4.1 | **dakopbouw op middenkern** |  | 13d | 2004-11-29 | 2004-12-16 |  | 53d |  |  |  |  |
| 86 | 4.1.1 | betonrand dakopbouw maken |  | 2d | 2004-11-29 | 2004-12-01 | 82SS+6d | 53d | 0d |  | m1 | kistpl |
| 87 | 4.1.2 | staalconstructie monteren |  | 4d | 2004-12-01 | 2004-12-07 | 86 | 53d | 0d |  | m2 | staalpl |
| 88 | 4.1.3 | liftmachine plaatsen | milestone | 0d | 2004-12-07 | 2004-12-07 | 87 | 53d | 0d |  |  | liftploeg |
| 89 | 4.1.4 | gevelbeplating aanbrengen |  | 3d | 2004-12-07 | 2004-12-10 | 88 | 53d | 0d |  | m2 | montpl |
| 90 | 4.1.5 | dakbeplating aanbrengen |  | 2d | 2004-12-10 | 2004-12-14 | 89 | 53d | 0d |  | m2 | montpl |
| 91 | 4.1.6 | dakbedekking dakopbouw |  | 2d | 2004-12-14 | 2004-12-16 | 90 | 53d |  |  | m2 | dakdek |
| 92 | 4.2 | **dakafwerking** |  | 19d | 2004-11-29 | 2004-12-24 |  | 47d |  |  |  |  |
| 93 | 4.2.1 | betonrand dakvloer storten |  | 5d | 2004-11-29 | 2004-12-06 | 82SS+6d | 47d | 0d |  | m1 | kistpl |
| 94 | 4.2.2 | isolatie afschotplaten aanbrengen |  | 9d | 2004-12-06 | 2004-12-17 | 93 | 47d | 0d |  | m2 | dakdek |
| 95 | 4.2.3 | dakbedekking aanbrengen |  | 9d | 2004-12-13 | 2004-12-24 | 94SS+5d | 47d |  |  | m2 | dakdek |
| 96 | 4.3 | **gevel linkervleugel** |  | 56.08d | 2004-11-08 | 2005-02-10 |  | 17.08d |  |  |  |  |
| 97 | 4.3.1 | metselen borstwering binnen |  | 15.38d | 2004-11-08 | 2004-11-29 | 68 | 46.41d | 0d |  | m2 | metsel |
| 98 | 4.3.2 | stelkozijnen monteren binnen |  | 14.29d | 2004-11-15 | 2004-12-03 | 97SS+5d | 61.79d |  |  | st | stelplo |
| 99 | 4.3.3 | metselen buitenspouw tot 1.70+ |  | 3d | 2004-12-01 | 2004-12-06 | 82SS+8d | 0d |  |  | m2 | metsel |
| 100 | 4.3.4 | gevelsteiger mee monteren |  | 20d | 2004-12-06 | 2005-01-17 | 99 | 41d |  |  | m2 | steiger |
| 101 | 4.3.5 | metselen buitenspouw tot 15,50+ |  | 18d | 2004-12-06 | 2005-01-13 | 99 | 0d |  |  | m2 | metsel |
| 102 | 4.3.6 | metselen buitenspouw tot dakrand |  | 4d | 2005-01-13 | 2005-01-19 | 101 | 0d |  |  | m2 | metsel |
| 103 | 4.3.7 | voegwerk buitengevel |  | 10d | 2005-01-19 | 2005-02-02 | 102 | 25d | 0d |  | m2 | metsel |
| 104 | 4.3.8 | demontage gevelsteiger |  | 10d | 2005-01-21 | 2005-02-04 | 103SS+2d | 25d | 0d |  | m2 | steiger |
| 105 | 4.3.9 | alu gevelkozijnen stellen |  | 10d | 2005-01-21 | 2005-02-04 | 104SS | 25d | 0d |  | st | stelplo |
| 106 | 4.3.10 | glas plaatsen in gevelkozijnen |  | 10d | 2005-01-25 | 2005-02-10 | 105SS+2d | 25d |  |  | st | stelplo |

| ID | WBS | Task | Duration | Start | Finish | Predecessors | Total slack | Free slack | Text1 | Text5 |
| --- | --- | --- | --- | --- | --- | --- | --- | --- | --- | --- |
| 107 | 4.4 | **gevel rechter vleugel** | 65.7d | 2004-11-29 | 2005-03-17 |  | 0d |  |  |  |
| 108 | 4.4.1 | metselen borstwering binnen | 15.38d | 2004-11-29 | 2004-12-20 | 97 | 46.41d | 0d | m2 | metsel |
| 109 | 4.4.2 | stelkozijnen monteren binnen | 14.29d | 2004-12-06 | 2004-12-24 | 108SS+5d | 46.41d |  | st | stelplo |
| 110 | 4.4.3 | metselen buitenspouw tot 1.70+ | 3d | 2005-01-19 | 2005-01-24 | 102 | 0d |  | m2 | metsel |
| 111 | 4.4.4 | gevelsteiger mee monteren | 20d | 2005-01-24 | 2005-02-23 | 110 | 16d |  | m2 | steiger |
| 112 | 4.4.5 | metselen buitenspouw tot 15,50+ | 18d | 2005-01-24 | 2005-02-21 | 110 | 0d |  | m2 | metsel |
| 113 | 4.4.6 | metselen buitenspouw tot dakrand | 4d | 2005-02-21 | 2005-02-25 | 112 | 0d |  | m2 | metsel |
| 114 | 4.4.7 | voegwerk buitengevel | 10d | 2005-02-25 | 2005-03-11 | 113 | 0d |  | m2 | metsel |
| 115 | 4.4.8 | demontage gevelsteiger | 10d | 2005-03-01 | 2005-03-15 | 114SS+2d | 0d |  | m2 | steiger |
| 116 | 4.4.9 | alu gevelkozijnen stellen | 10d | 2005-03-01 | 2005-03-15 | 115SS | 0d |  | st | stelplo |
| 117 | 4.4.10 | glas plaatsen in gevelkozijnen | 10d | 2005-03-03 | 2005-03-17 | 116SS+2d | 0d |  | st | stelplo |
